# eRA Maintenance Life Cycle WBS Template

Schedule from MS Project, 2001-12-20 to 2002-05-14.
RNSolutions

## Calendars

- Standard: Mon-Fri 08:00-12:00, 13:00-17:00; Sat-Sun off.

## Schedule

| ID | WBS | Task | Type | Duration | Start | Finish | Predecessors | Total slack | Free slack | Constraint | Text1 |
| --- | --- | --- | --- | --- | --- | --- | --- | --- | --- | --- | --- |
| 1 | 1 | **Maintenance Construction Phase** |  | 103d? | 2001-12-20 | 2002-05-13 |  | 1d |  |  |  |
| 2 | 1.1 | **Task Management Workflow - Maintenance Construction** |  | 103d | 2001-12-20 | 2002-05-13 |  | 1d |  |  |  |
| 3 | 1.1.1 | Develop Iteration Plan (artifact) |  | 1d | 2002-03-04 | 2002-03-04 |  | 50d | 0d | start no earlier than 2002-03-04 | Task Manager |
| 4 | 1.1.2 | GA Approval of Iteration Plan (planned changes in maintenance release) | milestone | 0d | 2002-03-04 | 2002-03-04 | 3 | 50d | 0d |  | Group Advocate |
| 5 | 1.1.3 | Provide Release Notification to Office of Communications and Outreach |  | 1d | 2002-03-05 | 2002-03-05 | 4, 49FF-20d | 50d |  |  | Task Manager |
| 6 | 1.1.4 | Develop/Maintain Review Records (artifact) |  | 1d | 2001-12-20 | 2001-12-20 |  | 103d |  |  | Task Manager |
| 7 | 1.1.5 | Develop Iteration Assessment (artifact) |  | 1d | 2002-05-13 | 2002-05-13 | 32 | 1d |  |  | Task Manager |
| 8 | 1.2 | **Business Modeling/Requirements Workflow - Maintenance Construction** |  | 1d | 2002-03-05 | 2002-03-05 |  | 50d |  |  |  |
| 9 | 1.2.1 | **Update Software Requirements Specification (artifact)** |  | 1d | 2002-03-05 | 2002-03-05 | 4 | 50d |  |  | Task Manager |
| 10 | 1.2.1.1 | Update Use Case Specification (artifact) |  | 1d | 2002-03-05 | 2002-03-05 | 4 | 50d |  |  | Task Manager |
| 11 | 1.2.1.2 | Update Use Case Model - (artifact) |  | 1d | 2002-03-05 | 2002-03-05 | 4 | 50d |  |  | Task Manager |
| 12 | 1.3 | **Analysis & Design Workflow - Maintenance Construction** |  | 1d? | 2002-03-05 | 2002-03-05 |  | 50d |  |  |  |
| 13 | 1.3.1 | **Update Software Architecture Document (artifact)** |  | 1d? | 2002-03-05 | 2002-03-05 |  | 50d |  |  |  |
| 14 | 1.3.1.1 | Update Design Model (artifact) |  | 1d? | 2002-03-05 | 2002-03-05 | 4 | 50d |  |  |  |
| 15 | 1.3.1.2 | Update Data Model (artifact) |  | 1d? | 2002-03-05 | 2002-03-05 | 4 | 50d |  |  |  |
| 16 | 1.4 | **Development/Implementation Workflow - Maintenance Construction** |  | 86d? | 2001-12-20 | 2002-04-19 |  | 18d |  |  | Development Lead |
| 17 | 1.4.1 | Develop Integration Build Plan (artifact) |  | 1d? | 2001-12-20 | 2001-12-20 |  | 103d |  |  | Development Lead |
| 18 | 3.3.9 | Build (artifact) |  | 1d? | 2002-03-05 | 2002-03-05 | 4 | 50d |  |  | Development Lead |
| 19 | 1.4.3 | Code Freeze | milestone | 0d | 2002-04-19 | 2002-04-19 |  | 0d |  | start no earlier than 2002-04-19 |  |
| 20 | 1.5 | **Integration Testing Workflow - Maintenance Construction** |  | 97d? | 2001-12-20 | 2002-05-03 |  | 7d |  |  |  |
| 21 | 1.5.1 | Develop Test Case (artifact) |  | 1d? | 2001-12-20 | 2001-12-20 |  | 103d |  |  | Test Lead |
| 22 | 1.5.2 | Develop Test Procedure (artifact) |  | 1d? | 2001-12-20 | 2001-12-20 |  | 103d |  |  | Test Lead |
| 23 | 1.5.3 | Conduct Integration Testing |  | 9d | 2002-04-22 | 2002-05-02 | 19FS+1d | 0d |  | finish no earlier than 2002-05-02 | Test Lead |
| 24 | 1.5.4 | Develop Test Results (artifact) |  | 1d | 2002-05-03 | 2002-05-03 | 23 | 0d |  |  | Test Lead |
| 25 | 1.5.5 | Approve for Acceptance Testing | milestone | 0d | 2002-05-03 | 2002-05-03 | 24 | 0d |  |  |  |
| 26 | 1.6 | Data Conversion/Pilot Workflow - Maintenance Construction (optional) |  | 1d? | 2001-12-20 | 2001-12-20 |  | 103d |  |  |  |

Notes:
- 5: Release notification includes: / * Name and version of module / * Basic highlights of new functionality (bullet points)

| ID | WBS | Task | Type | Duration | Start | Finish | Predecessors | Total slack | Free slack | Text1 |
| --- | --- | --- | --- | --- | --- | --- | --- | --- | --- | --- |
| 27 | 1.7 | **User Documentation & Training Workflow - Maintenance Construction** |  | 98d? | 2001-12-20 | 2002-05-06 |  | 6d |  | Technical Writer |
| 28 | 1.7.1 | Develop First Draft Release Notes (artifact) |  | 1d? | 2002-04-22 | 2002-04-22 | 19FS+1d | 16d |  | Technical Writer |
| 29 | 1.7.2 | Develop Second Draft Release Notes (artifact) |  | 1d? | 2002-05-06 | 2002-05-06 | 24 | 5d |  | Technical Writer |
| 30 | 1.7.3 | Develop/Update End-User Support Materials (artifact-optional) |  | 1d? | 2001-12-20 | 2001-12-20 |  | 103d |  | Technical Writer |
| 31 | 1.8 | **Deployment Workflow - Maintenance Construction** |  | 5d | 2002-05-06 | 2002-05-10 |  | 0d |  |  |
| 32 | 1.8.1 | Conduct Acceptance Testing |  | 5d | 2002-05-06 | 2002-05-10 | 25 | 0d |  | Test Lead? |
| 33 | 1.9 | GA Approval to Proceed to Transition |  | 1d? | 2002-05-13 | 2002-05-13 | 32 | 0d |  | Group Advocate |
| 34 | 2 | **Transition Phase** |  | 104d? | 2001-12-20 | 2002-05-14 |  | 0d |  |  |
| 35 | 2.1 | **Task Management Workflow - Maintenance Transition** |  | 1d? | 2001-12-20 | 2001-12-20 |  | 103d |  |  |
| 36 | 2.1.1 | Develop Iteration Assessment (Maintenance Transition Phase) (artifact) |  | 1d? | 2001-12-20 | 2001-12-20 |  | 103d |  | Task Manager |
| 37 | 2.1.2 | Develop/Maintain Review Records (artifact) |  | 1d? | 2001-12-20 | 2001-12-20 |  | 103d |  | Task Manager |
| 38 | 2.1.3 | Update/Close Out Release Cost and Schedule (artifact) |  | 1d? | 2001-12-20 | 2001-12-20 |  | 103d |  | Task Manager |
| 39 | 2.2 | Business Modeling/Requirements Workflow - Maintenance Transition |  | 1d? | 2001-12-20 | 2001-12-20 |  | 103d |  |  |
| 40 | 2.3 | Analysis & Design Workflow - Maintenance Transition |  | 1d? | 2001-12-20 | 2001-12-20 |  | 103d |  |  |
| 41 | 2.4 | Development/Implementation Workflow - Maintenance Transition |  | 1d? | 2001-12-20 | 2001-12-20 |  | 103d |  |  |
| 42 | 2.5 | Integration Testing Workflow - Maintenance Transition |  | 1d? | 2001-12-20 | 2001-12-20 |  | 103d |  |  |
| 43 | 2.6 | Data Conversion/Pilot Workflow - Maintenance Transition |  | 1d? | 2001-12-20 | 2001-12-20 |  | 103d |  |  |
| 44 | 2.7 | **User Documentation & Training Workflow - Maintenance Transition** |  | 1d | 2002-05-14 | 2002-05-14 |  | 0d |  |  |
| 45 | 2.7.1 | Develop Final Version Release Notes (artifact) |  | 1d | 2002-05-14 | 2002-05-14 | 29, 33 | 0d |  | Technical Writer |
| 46 | 2.8 | **Deployment Workflow - Maintenance Transition** |  | 4d | 2001-12-20 | 2001-12-25 |  | 100d |  |  |
| 47 | 2.8.1 | Deploy Release to Staging Area |  | 4d | 2001-12-20 | 2001-12-25 |  | 100d | 0d |  |
| 48 | 2.8.2 | Approve Production Deployment | milestone | 0d | 2001-12-25 | 2001-12-25 | 47 | 100d | 0d |  |
| 49 | 2.8.3 | Deploy to Production | milestone | 0d | 2001-12-25 | 2001-12-25 | 48 | 100d | 0d |  |
